# SUBPROYECTO A4 - RÍO LACRAMARCA

Schedule from Primavera P6, 2022-12-05 to 2023-05-01, data date 2022-12-04.

## Calendars

- Un turno - Río Lacramarca: Mon-Sat 08:00-16:00; Sun off.

## Schedule

| ID | WBS | Activity | Type | Duration | Start | Finish | Predecessors | Total float | Free float |
| --- | --- | --- | --- | --- | --- | --- | --- | --- | --- |
|  | 1 | **HITOS** |  |  | 2022-12-05 | 2023-05-01 |  |  |  |
|  | 1 | **Crontractuales** |  |  | 2022-12-05 | 2023-05-01 |  |  |  |
| A1000 |  | Buena Pro | milestone | 0d | 2022-12-05 | 2022-12-05 |  | 0d |  |
| A1010 |  | Inicio de obra - Acceso al Sitio | milestone | 0d | 2022-12-17 | 2022-12-17 | A1000 FS+11d | 0d |  |
| A1020 |  | Inicio de Excavación | milestone | 0d | 2022-12-26 | 2022-12-26 | A1490 SS | 46.25d | 0d |
| A2480 |  | Inicio de relleno de Dique | milestone | 0d | 2023-02-07 | 2023-02-07 | A1640 SS | 71d |  |
| A2490 |  | Culminación de Obras | milestone | 0d | 2023-05-01 | 2023-05-01 | A1485, A2450, A1430, A2440, A2480 | 0d |  |
|  | 2 | **Parciales** |  |  | 2023-04-13 | 2023-04-24 |  |  |  |
| A2640 |  | Fin Trabajos - Pampa del Toro | milestone | 0d | 2023-04-13 | 2023-04-13 | A1090, A1230, A1370, A1410, A1420 | 9d | 0d |
| A2650 |  | Fin Trabajos - Subproyecto A4 | milestone | 0d | 2023-04-24 | 2023-04-24 | A1440, A1460, A1540, A1550, A1600, A2100, A2260, A2510, A2460, A2470, A2430, A2610, A2160 | 0d |  |
|  | P | **PROCURA** |  |  |  |  |  |  |  |
|  | 40 | **PROCURA** |  |  |  |  |  |  |  |
|  | 50 | **CONSULTOR ESPECIALIZADO** |  |  |  |  |  |  |  |
|  | C | **CONSTRUCCIÓN** |  |  |  |  |  |  |  |
|  | 90 | **TRABAJOS PRELIMINARES** |  |  |  |  |  |  |  |
|  | 1 | **COSTOS DEL CONTRATISTA PRINCIPAL** |  |  |  |  |  |  |  |
|  | 2 | **GASTOS GENERALES** |  |  |  |  |  |  |  |
|  | 80 | **FACILIDADES DE OBRA** |  |  |  |  |  |  |  |
|  | 02 | **DEMOLICIONES** |  |  |  |  |  |  |  |
|  | 04 | **OBRAS DE DESVÍO TEMPORAL** |  |  |  |  |  |  |  |
|  | 70 | **OBRAS EXTERIORES** |  |  |  |  |  |  |  |
|  | 00 | **GENERAL** |  |  |  |  |  |  |  |
|  | 01 | **PREPARACIÓN DE SITIO** |  |  |  |  |  |  |  |
|  | 02 | **CAMINOS PROVISIONALES** |  |  |  |  |  |  |  |
|  | 03 | **PLANTACIÓN Y URBANISMO** |  |  |  |  |  |  |  |
|  | 05 | **MOBILIARIO Y EQUIPAMIENTO URBANO** |  |  |  |  |  |  |  |
|  | 10 | **CUERPOS DE TERRAPLÉN** |  |  |  |  |  |  |  |
|  | 11 | **SUPERFICIES DE TERRAPLÉN** |  |  |  |  |  |  |  |
|  | 12 | **MEJORAS EN LOS TERRAPLENES** |  |  |  |  |  |  |  |
|  | 13 | **CANALIZACIÓN** |  |  |  |  |  |  |  |
|  | 14 | **REFUERZO DE RIBERA DE RÍO** |  |  |  |  |  |  |  |
|  | 15 | **REFUERZO DE TALUDES** |  |  |  |  |  |  |  |
|  | 17 | **ESTRUCTURA DE CRUCE** |  |  |  |  |  |  |  |
|  | 21 | **REGISTROS Y CÁMARAS** |  |  |  |  |  |  |  |
|  | 22 | **DRENAJE URBANO** |  |  |  |  |  |  |  |
|  | 60 | **TRABAJOS DE RENOVACION** |  |  |  |  |  |  |  |
|  | 02 | **REPARACIÓN DE SERVICIOS EXISTENTES** |  |  |  |  |  |  |  |
|  | 30 | **ACABADOS** |  |  |  |  |  |  |  |
|  | 02 | **ACABADOS PARA PISOS** |  |  |  |  |  |  |  |
|  | 25 | **INSTALACIONES ESPECIALES** |  |  |  |  |  |  |  |
|  | 01 | **APOYOS PARA PUENTES** |  |  |  |  |  |  |  |
|  | 20 | **SUPERESTRUCTURA** |  |  |  |  |  |  |  |
|  | 1 | **(Nueva EDT)** |  |  |  |  |  |  |  |
|  | 00 | **GENERAL** |  |  |  |  |  |  |  |
|  | 01 | **LIMPIEZA DE SITIO** |  |  |  |  |  |  |  |
|  | T | **CIERRE** |  |  |  |  |  |  |  |
|  | 1 | **DESMOVILIZACIÓN** |  |  |  |  |  |  |  |
|  | 2 | **REPORTE FINAL** |  |  |  |  |  |  |  |
|  | 3 | **PAMPA DEL TORO** |  |  | 2023-01-31 | 2023-04-15 |  |  |  |
|  | 1 | **MEJORAMIENTO DE VIAS EXISTENTES** |  |  | 2023-01-31 | 2023-03-06 |  |  |  |
|  | 1 | **MOVIMIENTO DE TIERRAS** |  |  | 2023-01-31 | 2023-02-20 |  |  |  |
| A1030 |  | ROCE Y LIMPIEZA DE MALEZA |  | 18d | 2023-01-31 | 2023-02-20 | A1490 | 41.25d | 0d |
| A1040 |  | MEJORAMIENTO DE VIAS EXISTENTES |  | 18d | 2023-01-31 | 2023-02-20 | A1030 SS | 41.25d | 0d |

| ID | WBS | Activity | Duration | Start | Finish | Predecessors | Total float | Free float |
| --- | --- | --- | --- | --- | --- | --- | --- | --- |
|  | 2 | **REPOSICIÓN DE ESTRUCTURAS** |  | 2023-02-21 | 2023-03-01 |  |  |  |
| A1050 |  | DEMOLICIÓN DE ESTRUCTURAS EXISTENTES | 1.25d | 2023-02-21 | 2023-02-22 | A1040, A1030 | 41.25d | 0d |
| A1060 |  | REPOSICIÓN DE PASE DE AGUA TUBERÍA HDPE Ø=36" | 1.25d | 2023-02-22 | 2023-02-23 | A1050 | 41.25d | 0d |
| A1070 |  | REPOSICIÓN DE PASE DE AGUA TUBERÍA HDPE Ø=24" | 1.25d | 2023-02-23 | 2023-02-24 | A1060 | 41.25d | 0d |
| A1080 |  | SUMINISTRO Y MONTAJE DE LOSAS DE C°A° 1.6mx1.0mx0.20m EN PASE DE AGUA | 4d | 2023-02-24 | 2023-03-01 | A1070 | 41.25d | 0d |
|  | 3 | **ESTRUCTURAS DE CONCRETO** |  | 2023-03-01 | 2023-03-06 |  |  |  |
| A1100 |  | ENCOFRADO Y DESENCOFRADO NORMAL | 3d | 2023-03-01 | 2023-03-04 | A1080 | 41.25d | 0d |
| A1090 |  | CONCRETO 175 Kg/cm2 | 1.25d | 2023-03-04 | 2023-03-06 | A1100 | 41.25d | 32.25d |
|  | 4 | **DIQUES Y PROTECCIÓN DE CAUCE CON ENROCADO** |  | 2023-01-31 | 2023-04-11 |  |  |  |
|  | 1 | **DIQUE DE TIERRA COMPACTADA A4-PT-D-05** |  | 2023-01-31 | 2023-04-08 |  |  |  |
| A1110 |  | DESBROCE Y LIMPIEZA EN ZONA NO BOSCOSA | 1.25d | 2023-01-31 | 2023-02-01 | A1570 | 53.25d | 0d |
| A1120 |  | EXCAVACIÓN EN TERRENO NATURAL CON EQUIPO | 1.25d | 2023-02-15 | 2023-02-16 | A1110, A2150 | 41.5d | 0d |
| A1130 |  | PERFILADO Y COMPACTACIÓN EN ZONA DE CORTE | 2d | 2023-02-23 | 2023-02-24 | A1120, A2170 | 35.75d | 0d |
| A1140 |  | CONFORMACIÓN DE CUERPO DE DIQUE | 2d | 2023-03-06 | 2023-03-08 | A1130, A2180 | 28.5d | 0d |
| A1160 |  | GEOTEXTIL NO TEJIDO 400 G/M2, INC. COLOCACIÓN | 1.25d | 2023-03-10 | 2023-03-11 | A1140, A2200 | 27.75d | 0d |
| A1170 |  | COLOCACION Y ACOMODO DE ROCA EN UÑA DE DIQUE | 2d | 2023-03-22 | 2023-03-24 | A1160, A2210 | 18.5d | 0d |
| A1180 |  | COLOCACION Y ACOMODO DE ROCA EN TALUD DE DIQUE | 1.25d | 2023-04-05 | 2023-04-06 | A1170, A2220 | 9d | 0d |
| A1150 |  | CONFORMACIÓN DE MATERIAL GRANULAR EN CORONA DE DIQUE | 1.25d | 2023-04-07 | 2023-04-08 | A1180, A2190 | 10.5d | 0d |
|  | 2 | **DIQUE DE TIERRA COMPACTADA A4-PT-D-04** |  | 2023-02-01 | 2023-04-10 |  |  |  |
| A1190 |  | DESBROCE Y LIMPIEZA EN ZONA NO BOSCOSA | 1.25d | 2023-02-01 | 2023-02-02 | A1110 | 54d | 0d |
| A1200 |  | EXCAVACIÓN EN TERRENO NATURAL CON EQUIPO | 1.25d | 2023-02-16 | 2023-02-17 | A1190, A1120 | 42.25d | 0d |
| A1210 |  | PERFILADO Y COMPACTACIÓN EN ZONA DE CORTE | 1.25d | 2023-02-25 | 2023-02-27 | A1200, A1130 | 36.5d | 0d |
| A1220 |  | CONFORMACIÓN DE CUERPO DE DIQUE | 1.25d | 2023-03-08 | 2023-03-09 | A1210, A1140 | 28.5d | 0d |
| A1240 |  | GEOTEXTIL NO TEJIDO 400 G/M2, INC. COLOCACIÓN | 1.25d | 2023-03-11 | 2023-03-13 | A1220, A1160 | 28.5d | 0d |
| A1250 |  | COLOCACION Y ACOMODO DE ROCA EN UÑA DE DIQUE | 1.25d | 2023-03-24 | 2023-03-25 | A1240, A1170 | 18.5d | 0d |
| A1260 |  | COLOCACION Y ACOMODO DE ROCA EN TALUD DE DIQUE | 1.25d | 2023-04-07 | 2023-04-08 | A1250, A1180 | 9d | 0d |
| A1230 |  | CONFORMACIÓN DE MATERIAL GRANULAR EN CORONA DE DIQUE | 1.25d | 2023-04-08 | 2023-04-10 | A1260, A1150 | 10.5d | 0d |

| ID | WBS | Activity | Duration | Start | Finish | Predecessors | Total float | Free float |
| --- | --- | --- | --- | --- | --- | --- | --- | --- |
|  | 3 | **PROTECCION DE TALUDES** |  | 2023-02-02 | 2023-04-11 |  |  |  |
| A1270 |  | DESBROCE Y LIMPIEZA EN ZONA NO BOSCOSA | 1.25d | 2023-02-02 | 2023-02-03 | A1190 | 54d | 0d |
| A1280 |  | EXCAVACIÓN EN TERRENO NATURAL CON EQUIPO | 2d | 2023-02-17 | 2023-02-20 | A1270, A1200 | 42.25d | 0d |
| A1290 |  | PERFILADO Y COMPACTACIÓN EN ZONA DE CORTE | 1.25d | 2023-02-27 | 2023-02-28 | A1280, A1210 | 36.5d | 0d |
| A1300 |  | RELLENO ESTRUCTURAL CON MATERIAL PROPIO | 3d | 2023-03-09 | 2023-03-13 | A1290, A1220 | 28.5d | 0d |
| A1310 |  | GEOTEXTIL NO TEJIDO 400 G/M2, INC. COLOCACIÓN | 1.25d | 2023-03-13 | 2023-03-14 | A1300, A1240 | 28.5d | 10d |
| A1320 |  | COLOCACION Y ACOMODO DE ROCA EN UÑA DE DIQUE | 2d | 2023-03-25 | 2023-03-28 | A1310, A1250 | 18.5d | 9.5d |
| A1330 |  | COLOCACION Y ACOMODO DE ROCA EN TALUD DE DIQUE | 2d | 2023-04-08 | 2023-04-11 | A1320, A1260 | 9d | 0d |
|  | 2 | **REPOSICIÓN DE CAMINO DE ACCESO A4-RC-1** |  | 2023-02-03 | 2023-04-11 |  |  |  |
| A1340 |  | DESBROCE Y LIMPIEZA EN ZONA NO BOSCOSA | 1.25d | 2023-02-03 | 2023-02-04 | A1270 | 60.5d | 0d |
| A1350 |  | EXCAVACIÓN EN MATERIAL SUELTO CON EQUIPO | 1.25d | 2023-02-20 | 2023-02-21 | A1340, A1280 | 48d | 0d |
| A1360 |  | PERFILADO Y COMPACTACIÓN EN ZONA DE CORTE | 1.25d | 2023-02-28 | 2023-03-01 | A1350, A1290 | 42.25d | 0d |
| A1370 |  | MATERIAL AFIRMADO e=25 cm | 1.25d | 2023-04-10 | 2023-04-11 | A1360, A1300, A1230 | 10.5d | 1.5d |
|  | 3 | **PROTECCION DEL CAUCE CON ENROCADO** |  | 2023-02-06 | 2023-04-13 |  |  |  |
| A1380 |  | DESBROCE Y LIMPIEZA EN ZONA NO BOSCOSA | 1.25d | 2023-02-06 | 2023-02-07 | A1340 | 60.5d | 12.5d |
| A1390 |  | EXCAVACIÓN EN MATERIAL SUELTO CON EQUIPO | 1.25d | 2023-02-21 | 2023-02-22 | A1380, A1350 | 48d | 5.75d |
| A1400 |  | PERFILADO Y COMPACTACIÓN CON EQUIPO DE FONDO DE EXCAVACIÓN | 1.25d | 2023-03-01 | 2023-03-02 | A1390, A1360 | 42.25d | 0d |
| A1410 |  | COLOCACION DE ROCA EN CAUCE | 2d | 2023-04-11 | 2023-04-13 | A1400, A1330 | 9d | 0d |
|  | 5 | **PROGRAMA DE CIERRE DE OBRA** |  | 2023-03-03 | 2023-04-15 |  |  |  |
| A1420 |  | ACONDICIONAMIENTO DE DEPOSITOS DE MATERIALES EXCEDENTES (DME) | 1d | 2023-03-03 | 2023-03-03 | A1050, A1110, A1120, A1130, A1190, A1200, A1210, A1270, A1280, A1290, A1340, A1350, A1360, A1380, A1390, A1400 | 43.25d | 34.25d |
| A1430 |  | RESTAURACIÓN DE ÁREAS DE INSTALACIONES PROVISIONALES | 2d | 2023-04-13 | 2023-04-15 | A2640 | 13d |  |
|  | 6 | **SUBPROYECTO A4** |  | 2022-12-17 | 2023-05-01 |  |  |  |
|  | 1 | **OBRAS PRELIMINARES** |  | 2022-12-26 | 2023-04-22 |  |  |  |
| A1460 |  | MANTENIMIENTO DE TRÁNSITO Y SEGURIDAD VIAL | 102d | 2022-12-26 | 2023-04-22 | A1500 SS | 0.25d |  |
| A1450 |  | INSTALACIONES PROVISIONALES PARA LA OBRA | 10d | 2022-12-28 | 2023-01-07 | A1500 SS+2d | 0d |  |
| A1440 |  | CARTEL DE IDENTIFICACIÓN OBRA 4.80 x 3.60 m. | 2d | 2023-01-09 | 2023-01-10 | A1450 | 88.25d |  |

| ID | WBS | Activity | Duration | Start | Finish | Predecessors | Total float | Free float |
| --- | --- | --- | --- | --- | --- | --- | --- | --- |
|  | 2 | **TRABAJOS PRELIMINARES** |  | 2022-12-17 | 2023-05-01 |  |  |  |
| A1470 |  | MOVILIZACION DE EQUIPOS | 18d | 2022-12-17 | 2023-01-06 | A1010 | 0d |  |
| A1480 |  | TOPOGRAFÍA Y GEORREFERENCIACIÓN | 109d | 2022-12-19 | 2023-04-24 | A1470 SS+1d | 0d |  |
| A1485 |  | DESMOVILIZACION DE EQUIPOS | 6d | 2023-04-24 | 2023-05-01 | A2640, A2650 | 0d |  |
|  | 3 | **MEJORAMIENTO DE VÍAS EXISTENTES** |  | 2022-12-26 | 2023-02-15 |  |  |  |
|  | 1 | **MOVIMIENTO DE TIERRAS** |  | 2022-12-26 | 2023-01-30 |  |  |  |
| A1490 |  | ROCE Y LIMPIEZA DE MALEZA | 31d | 2022-12-26 | 2023-01-30 | A1480 SS+6d | 0d |  |
| A1500 |  | MEJORAMIENTO DE VIAS EXISTENTES | 31d | 2022-12-26 | 2023-01-30 | A1490 SS | 0d |  |
|  | 2 | **REPOSICIÓN DE ESTRUCTURAS** |  | 2023-01-31 | 2023-02-15 |  |  |  |
| A1510 |  | DEMOLICIÓN DE ESTRUCTURAS EXISTENTES | 1.25d | 2023-01-31 | 2023-02-01 | A1500 | 57.5d | 0d |
| A1520 |  | REPOSICIÓN DE PASE DE AGUA TUBO HDPE Ø=24" | 1.25d | 2023-02-01 | 2023-02-02 | A1510 | 57.5d | 0d |
| A1530 |  | REPOSICIÓN DE PASE DE AGUA TUBO HDPE Ø=36" | 1.25d | 2023-02-02 | 2023-02-03 | A1520 | 57.5d | 0d |
| A1540 |  | SUMINISTRO Y MONTAJE DE PANELES DE C°A° 2.20mx1.0mx0.20m en Pase de Agua | 10d | 2023-02-03 | 2023-02-15 | A1530 | 57.5d |  |
|  | 3 | **CABEZAL DE ENTRADA Y SALIDA** |  | 2023-02-02 | 2023-02-07 |  |  |  |
| A1560 |  | ENCOFRADO Y DESENCOFRADO NORMAL | 3d | 2023-02-02 | 2023-02-06 | A1520 | 64.75d | 0d |
| A1550 |  | CONCRETO 175 Kg/cm2 | 1d | 2023-02-06 | 2023-02-07 | A1560 | 64.75d |  |
|  | 4 | **DESCOLMATACIÓN DE CAUCE** |  | 2022-12-30 | 2023-04-05 |  |  |  |
|  | 1 | **DESBROCE Y LIMPIEZA EN ZONA NO BOSCOSA** |  | 2022-12-30 | 2023-01-30 |  |  |  |
| A1570 |  | DESBROCE Y LIMPIEZA EN ZONA NO BOSCOSA SUBPROYECTO A4 | 27d | 2022-12-30 | 2023-01-30 | A1450 SS+2d | 0d |  |
|  | 2 | **DESCOLMATACIÓN EN CAUCE NATURAL** |  | 2023-01-31 | 2023-04-05 |  |  |  |
| A1580 |  | DESCOLMATACIÓN DE CAUCE NATURAL EN RIO LACRAMARCA | 47d | 2023-01-31 | 2023-03-25 | A1570 | 15.25d | 0d |
| A1590 |  | DESCOLMATACIÓN DE CAUCE NATURAL EN BRAZO SECUNDARIO | 6d | 2023-03-27 | 2023-04-01 | A1580 | 15.25d | 0d |
| A1600 |  | DESCOLMATACIÓN DE CAUCE NATURAL EN QUEBRADA PAMPA DEL TORO | 3d | 2023-04-03 | 2023-04-05 | A1590 | 15.25d |  |
|  | 5 | **DIQUES DE TIERRA COMPACTADA CON ENROCADO** |  | 2023-01-02 | 2023-04-24 |  |  |  |
|  | 1 | **MÁRGEN DERECHA** |  | 2023-01-02 | 2023-04-24 |  |  |  |
|  | 1 | **DIQUE DE TIERRA COMPACTADA A4-D-01** |  | 2023-01-02 | 2023-03-28 |  |  |  |
| A1610 |  | EXCAVACIÓN EN TERRENO NATURAL CON EQUIPO | 30d | 2023-01-02 | 2023-02-04 | A1570 SS+2d | 0d |  |
| A1630 |  | PERFILADO Y COMPACTACIÓN EN ZONA DE CORTE | 32d | 2023-01-04 | 2023-02-09 | A1610 SS+2d | 0d |  |
| A1620 |  | EXCAVACIÓN EN UÑA CON EQUIPO | 23d | 2023-01-16 | 2023-02-10 | A1610 SS+12d | 8d | 1d |
| A1660 |  | GEOTEXTIL NO TEJIDO 400 G/M2, INC. COLOCACIÓN | 11d | 2023-01-25 | 2023-02-06 | A1630 SS+18d | 0d |  |
| A1670 |  | COLOCACION Y ACOMODO DE ROCA EN UÑA DE DIQUE | 35d | 2023-01-27 | 2023-03-08 | A1620 SS+2d, A1660 SS+2d | 0d |  |
| A1680 |  | COLOCACION Y ACOMODO DE ROCA EN TALUD DE DIQUE | 47d | 2023-01-30 | 2023-03-24 | A1670 SS+2d | 0d |  |
| A1690 |  | PREPARACIÓN DE FUNDACIÓN DE CUERPO DE DIQUE | 1.25d | 2023-02-06 | 2023-02-07 | A1610 | 22.75d | 0d |
| A1640 |  | CONFORMACIÓN DE CUERPO DE DIQUE CON MATERIAL PROPIO | 1.25d | 2023-02-07 | 2023-02-08 | A1690 | 23.5d | 0d |
| A1650 |  | CONFORMACIÓN DE MATERIAL GRANULAR EN CORONA DE DIQUE | 13d | 2023-03-14 | 2023-03-28 | A1680 FF+3d | 15d |  |

| ID | WBS | Activity | Duration | Start | Finish | Predecessors | Total float | Free float |
| --- | --- | --- | --- | --- | --- | --- | --- | --- |
|  | 2 | **DIQUE DE TIERRA COMPACTADA A4-BS-D-01** |  | 2023-02-06 | 2023-04-21 |  |  |  |
| A1880 |  | EXCAVACIÓN EN TERRENO NATURAL CON EQUIPO | 8d | 2023-02-06 | 2023-02-14 | A1610 | 16d | 0d |
| A1890 |  | EXCAVACIÓN EN UÑA CON EQUIPO | 9d | 2023-02-13 | 2023-02-22 | A1620, A1880 SS+6d | 43d | 0d |
| A1900 |  | PERFILADO Y COMPACTACIÓN EN ZONA DE CORTE | 10d | 2023-02-13 | 2023-02-23 | A1880 SS+6d, A1630 | 38.25d | 0d |
| A1960 |  | PREPARACIÓN DE FUNDACIÓN DE CUERPO DE DIQUE | 2d | 2023-02-15 | 2023-02-16 | A1880, A1690 | 16d | 0d |
| A1910 |  | CONFORMACIÓN DE CUERPO DE DIQUE CON MATERIAL PROPIO | 13d | 2023-02-17 | 2023-03-03 | A1960, A1640 | 16d | 0d |
| A1930 |  | GEOTEXTIL NO TEJIDO 400 G/M2, INC. COLOCACIÓN | 5d | 2023-02-28 | 2023-03-04 | A1910 SS+9d, A1660 | 16d | 0.25d |
| A1940 |  | COLOCACION Y ACOMODO DE ROCA EN UÑA DE DIQUE | 14d | 2023-03-09 | 2023-03-24 | A1930 SS+3d, A1670 | 11d | 0d |
| A1950 |  | COLOCACION Y ACOMODO DE ROCA EN TALUD DE DIQUE | 18d | 2023-03-25 | 2023-04-14 | A1680, A1940 SS+3d | 0d |  |
| A1920 |  | CONFORMACIÓN DE MATERIAL GRANULAR EN CORONA DE DIQUE | 6d | 2023-04-15 | 2023-04-21 | A1950, A1650 | 0d |  |
|  | 3 | **DIQUE DE TIERRA COMPACTADA A4-D-00** |  | 2023-02-15 | 2023-04-24 |  |  |  |
| A2060 |  | EXCAVACIÓN EN TERRENO NATURAL CON EQUIPO | 2d | 2023-02-15 | 2023-02-16 | A1880 | 44.25d | 0d |
| A2070 |  | EXCAVACIÓN EN UÑA CON EQUIPO | 2d | 2023-02-23 | 2023-02-24 | A2060 SS+3d, A1890 | 43d | 24d |
| A2080 |  | PERFILADO Y COMPACTACIÓN EN ZONA DE CORTE | 2d | 2023-02-24 | 2023-02-25 | A2060, A1900 | 38.25d | 0d |
| A2140 |  | PREPARACIÓN DE FUNDACIÓN DE CUERPO DE DIQUE | 1.25d | 2023-02-27 | 2023-02-28 | A2080, A1960 | 38.25d | 3.75d |
| A2090 |  | CONFORMACIÓN DE CUERPO DE DIQUE CON MATERIAL PROPIO | 1.25d | 2023-03-04 | 2023-03-06 | A2140, A1910 | 34.5d | 0d |
| A2110 |  | GEOTEXTIL NO TEJIDO 400 G/M2, INC. COLOCACIÓN | 1.25d | 2023-03-06 | 2023-03-07 | A2090, A1930 | 34.5d | 15.5d |
| A2120 |  | COLOCACION Y ACOMODO DE ROCA EN UÑA DE DIQUE | 2d | 2023-03-25 | 2023-03-27 | A2110, A2070, A1940 | 19d | 16d |
| A2130 |  | COLOCACION Y ACOMODO DE ROCA EN TALUD DE DIQUE | 3d | 2023-04-15 | 2023-04-18 | A2120, A1950 | 3d |  |
| A2100 |  | CONFORMACIÓN DE MATERIAL GRANULAR EN CORONA DE DIQUE | 1.25d | 2023-04-22 | 2023-04-24 | A2130, A1920 | 0d |  |
|  | 2 | **MÁRGEN IZQUIERDA** |  | 2023-01-03 | 2023-04-06 |  |  |  |
|  | 1 | **DIQUE DE TIERRA COMPACTADA A4-I-01** |  | 2023-01-03 | 2023-02-25 |  |  |  |
| A1700 |  | EXCAVACIÓN EN TERRENO NATURAL CON EQUIPO | 10d | 2023-01-03 | 2023-01-13 | A1570 SS+3d | 9d | 0d |
| A1720 |  | PERFILADO Y COMPACTACIÓN EN ZONA DE CORTE | 12d | 2023-01-06 | 2023-01-19 | A1700 SS+3d | 9d | 0d |
| A1710 |  | EXCAVACIÓN EN UÑA CON EQUIPO | 10d | 2023-01-10 | 2023-01-20 | A1700 SS+6d | 58.25d | 2.75d |
| A1750 |  | GEOTEXTIL NO TEJIDO 400 G/M2, INC. COLOCACIÓN | 5d | 2023-01-16 | 2023-01-21 | A1720 SS+8.75d | 9d | 0d |
| A1760 |  | COLOCACION Y ACOMODO DE ROCA EN UÑA DE DIQUE | 15d | 2023-01-19 | 2023-02-06 | A1750 SS+3d | 9d | 0d |
| A1780 |  | PREPARACIÓN DE FUNDACIÓN DE CUERPO DE DIQUE | 1.25d | 2023-01-20 | 2023-01-21 | A1720 | 35d | 7d |
| A1770 |  | COLOCACION Y ACOMODO DE ROCA EN TALUD DE DIQUE | 24d | 2023-01-23 | 2023-02-20 | A1760 SS+3d | 9d | 0d |
| A1730 |  | CONFORMACIÓN DE CUERPO DE DIQUE CON MATERIAL PROPIO | 1.25d | 2023-01-30 | 2023-01-31 | A1780, A2370 | 28.75d | 8.75d |
| A1740 |  | CONFORMACIÓN DE MATERIAL GRANULAR EN CORONA DE DIQUE | 5d | 2023-02-20 | 2023-02-25 | A1770 | 32.5d | 15d |

| ID | WBS | Activity | Duration | Start | Finish | Predecessors | Total float | Free float |
| --- | --- | --- | --- | --- | --- | --- | --- | --- |
|  | 2 | **DIQUE DE TIERRA COMPACTADA A4-I-02** |  | 2023-01-14 | 2023-03-23 |  |  |  |
| A1790 |  | EXCAVACIÓN EN TERRENO NATURAL CON EQUIPO | 21d | 2023-01-14 | 2023-02-07 | A1700 | 11.5d | 0d |
| A1810 |  | PERFILADO Y COMPACTACIÓN EN ZONA DE CORTE | 17d | 2023-01-20 | 2023-02-08 | A1790 SS+3d, A1720 | 14.5d | 0d |
| A1800 |  | EXCAVACIÓN EN UÑA CON EQUIPO | 12d | 2023-01-24 | 2023-02-07 | A1710, A1790 SS+8.75d | 55.5d | 9d |
| A1840 |  | GEOTEXTIL NO TEJIDO 400 G/M2, INC. COLOCACIÓN | 6d | 2023-02-03 | 2023-02-09 | A1810 SS+12d, A1750 | 16.25d | 0d |
| A1850 |  | COLOCACION Y ACOMODO DE ROCA EN UÑA DE DIQUE | 18d | 2023-02-07 | 2023-02-28 | A1840 SS+3.75d, A1760 | 16.25d | 6.75d |
| A1870 |  | PREPARACIÓN DE FUNDACIÓN DE CUERPO DE DIQUE | 1.25d | 2023-02-09 | 2023-02-10 | A1810, A1780 | 19.25d | 0d |
| A1820 |  | CONFORMACIÓN DE CUERPO DE DIQUE CON MATERIAL PROPIO | 1.25d | 2023-02-10 | 2023-02-11 | A1870, A1730 | 20d | 8.5d |
| A1860 |  | COLOCACION Y ACOMODO DE ROCA EN TALUD DE DIQUE | 20d | 2023-02-20 | 2023-03-15 | A1850 SS+3.75d, A1770 | 9d | 0d |
| A1830 |  | CONFORMACIÓN DE MATERIAL GRANULAR EN CORONA DE DIQUE | 7d | 2023-03-15 | 2023-03-23 | A1860, A1740 | 17.5d | 7d |
|  | 3 | **DIQUE DE TIERRA COMPACTADA A4-BS-I-01** |  | 2023-02-08 | 2023-04-05 |  |  |  |
| A1970 |  | EXCAVACIÓN EN TERRENO NATURAL CON EQUIPO | 4d | 2023-02-08 | 2023-02-11 | A1790 | 11.5d | 0d |
| A1990 |  | PERFILADO Y COMPACTACIÓN EN ZONA DE CORTE | 6d | 2023-02-13 | 2023-02-18 | A1970, A1810 | 11.5d | 0d |
| A1980 |  | EXCAVACIÓN EN UÑA CON EQUIPO | 7d | 2023-02-17 | 2023-02-25 | A1800, A1970 SS+8.75d | 46.5d | 0d |
| A2050 |  | PREPARACIÓN DE FUNDACIÓN DE CUERPO DE DIQUE | 2d | 2023-02-20 | 2023-02-21 | A1990, A1870 | 11.5d | 0d |
| A2000 |  | CONFORMACIÓN DE CUERPO DE DIQUE CON MATERIAL PROPIO | 9d | 2023-02-22 | 2023-03-03 | A2050, A1820 | 11.5d | 0d |
| A2020 |  | GEOTEXTIL NO TEJIDO 400 G/M2, INC. COLOCACIÓN | 4d | 2023-03-03 | 2023-03-08 | A2000 SS+8.75d, A1840 | 11.5d | 0d |
| A2030 |  | COLOCACION Y ACOMODO DE ROCA EN UÑA DE DIQUE | 10d | 2023-03-08 | 2023-03-20 | A2020 SS+3.75d, A1850 | 11.5d | 0d |
| A2040 |  | COLOCACION Y ACOMODO DE ROCA EN TALUD DE DIQUE | 14d | 2023-03-15 | 2023-03-31 | A2030 SS+3.75d, A1860 | 9d | 0d |
| A2010 |  | CONFORMACIÓN DE MATERIAL GRANULAR EN CORONA DE DIQUE | 4d | 2023-03-31 | 2023-04-05 | A2040, A1830 | 10.5d | 0d |
|  | 4 | **DIQUE DE TIERRA COMPACTADA A4-I-00** |  | 2023-02-13 | 2023-04-06 |  |  |  |
| A2150 |  | EXCAVACIÓN EN TERRENO NATURAL CON EQUIPO | 2d | 2023-02-13 | 2023-02-14 | A1970 | 39d | 0d |
| A2170 |  | PERFILADO Y COMPACTACIÓN EN ZONA DE CORTE | 3d | 2023-02-20 | 2023-02-22 | A2150, A1990 | 35d | 0d |
| A2230 |  | PREPARACIÓN DE FUNDACIÓN DE CUERPO DE DIQUE | 1.25d | 2023-02-23 | 2023-02-24 | A2170, A2050 | 35d | 6.75d |
| A2160 |  | EXCAVACIÓN EN UÑA CON EQUIPO | 2d | 2023-02-25 | 2023-02-28 | A2150, A1980 | 46.5d |  |
| A2180 |  | CONFORMACIÓN DE CUERPO DE DIQUE CON MATERIAL PROPIO | 1.25d | 2023-03-04 | 2023-03-06 | A2230, A2000 | 28.25d | 0d |
| A2200 |  | GEOTEXTIL NO TEJIDO 400 G/M2, INC. COLOCACIÓN | 1.25d | 2023-03-08 | 2023-03-09 | A2180, A2020 | 25.75d | 0d |
| A2210 |  | COLOCACION Y ACOMODO DE ROCA EN UÑA DE DIQUE | 2d | 2023-03-20 | 2023-03-22 | A2200, A2030 | 17.25d | 0d |
| A2220 |  | COLOCACION Y ACOMODO DE ROCA EN TALUD DE DIQUE | 4d | 2023-03-31 | 2023-04-05 | A2210, A2040 | 9d | 0d |
| A2190 |  | CONFORMACIÓN DE MATERIAL GRANULAR EN CORONA DE DIQUE | 1.25d | 2023-04-05 | 2023-04-06 | A2220, A2010 | 10.5d | 0d |

| ID | WBS | Activity | Duration | Start | Finish | Predecessors | Total float | Free float |
| --- | --- | --- | --- | --- | --- | --- | --- | --- |
|  | 6 | **RAMPAS** |  | 2023-02-17 | 2023-04-08 |  |  |  |
| A2240 |  | EXCAVACIÓN EN TERRENO NATURAL CON EQUIPO | 7d | 2023-02-17 | 2023-02-24 | A2060 | 44.25d | 7.25d |
| A2250 |  | CONFORMACIÓN DE CUERPO DE RAMPA CON MATERIAL PROPIO | 3d | 2023-03-06 | 2023-03-09 | A2240, A2090 | 37d | 24.75d |
| A2260 |  | CONFORMACIÓN DE MATERIAL GRANULAR EN CORONA DE DIQUE | 2d | 2023-04-07 | 2023-04-08 | A2250, A2190 | 12.25d |  |
|  | 7 | **MUROS DE CONCRETO ARMADO SOBRE CANAL HUACA NEPEÑA** |  | 2023-01-09 | 2023-04-17 |  |  |  |
|  | 1 | **MURO A4-MU-D-01** |  | 2023-01-09 | 2023-04-04 |  |  |  |
|  | 1 | **MOVIMIENTO DE TIERRAS** |  | 2023-01-09 | 2023-04-04 |  |  |  |
| A2270 |  | EXCAVACIÓN ESTRUCTURAL PARA OBRAS DE ARTE | 3d | 2023-01-09 | 2023-01-11 | A1450 | 5.5d | 0d |
| A2280 |  | RELLENO ESTRUCTURAL PARA OBRAS DE ARTE CON MATERIAL PROPIO | 6d | 2023-03-28 | 2023-04-04 | A2315 FS+18d | 10.5d | 5d |
|  | 2 | **OBRAS DE CONCRETO** |  | 2023-01-12 | 2023-03-07 |  |  |  |
|  | 1 | **BASE** |  | 2023-01-12 | 2023-01-24 |  |  |  |
| A2290 |  | CONCRETO F'C=100 Kg/cm2 | 1.25d | 2023-01-12 | 2023-01-13 | A2270 | 5.5d | 0d |
| A2295 |  | ACERO DE REFUERZO Fy=4200 Kg/cm2 | 5d | 2023-01-13 | 2023-01-19 | A2290 | 5.5d | 0d |
| A2300 |  | CONCRETO F'C=280 Kg/cm2 - BASE | 4d | 2023-01-19 | 2023-01-24 | A2295 | 5.5d | 0d |
|  | 2 | **MURO** |  | 2023-02-13 | 2023-03-07 |  |  |  |
| A2305 |  | ACERO DE REFUERZO Fy=4200 Kg/cm2 | 10d | 2023-02-13 | 2023-02-24 | A2300 FS+17.5d | 5.5d | 0d |
| A2330 |  | SUMINISTRO E INSTALACIÓN DE TEKNOPORT e=3/4" | 10d | 2023-02-13 | 2023-02-24 | A2305 SS | 10.5d | 0d |
| A2340 |  | JUNTA con sellante expandible 1" x 3/4" | 10d | 2023-02-13 | 2023-02-24 | A2305 SS | 10.5d | 0d |
| A2310 |  | ENCOFRADO Y DESENCOFRADO | 11d | 2023-02-16 | 2023-03-01 | A2305 SS+3d | 5.5d | 0d |
| A2315 |  | CONCRETO F'C=280 Kg/cm2 - MURO | 5d | 2023-03-01 | 2023-03-07 | A2310 | 10.5d | 0d |
|  | 2 | **MURO A4-MU-I-01** |  | 2023-01-12 | 2023-04-17 |  |  |  |
|  | 1 | **MOVIMIENTO DE TIERRAS** |  | 2023-01-12 | 2023-04-17 |  |  |  |
| A2500 |  | EXCAVACIÓN ESTRUCTURAL PARA OBRAS DE ARTE | 3d | 2023-01-12 | 2023-01-14 | A2270 | 13.5d | 0d |
| A2510 |  | RELLENO ESTRUCTURAL PARA OBRAS DE ARTE CON MATERIAL PROPIO | 6d | 2023-04-10 | 2023-04-17 | A2580 FS+18d, A2280 | 5.5d |  |

| ID | WBS | Activity | Duration | Start | Finish | Predecessors | Total float | Free float |
| --- | --- | --- | --- | --- | --- | --- | --- | --- |
|  | 2 | **OBRAS DE CONCRETO** |  | 2023-01-16 | 2023-03-20 |  |  |  |
|  | 1 | **BASE** |  | 2023-01-16 | 2023-01-30 |  |  |  |
| A2520 |  | CONCRETO F'C=100 Kg/cm2 | 1.25d | 2023-01-16 | 2023-01-17 | A2500, A2290 | 13.5d | 2d |
| A2590 |  | ACERO DE REFUERZO Fy=4200 Kg/cm2 | 5d | 2023-01-19 | 2023-01-25 | A2520, A2295 | 11.5d | 0d |
| A2530 |  | CONCRETO F'C=280 Kg/cm2 - BASE | 4d | 2023-01-25 | 2023-01-30 | A2590, A2300 | 11.5d | 1d |
|  | 2 | **MURO** |  | 2023-02-24 | 2023-03-20 |  |  |  |
| A2550 |  | ACERO DE REFUERZO Fy=4200 Kg/cm2 | 10d | 2023-02-24 | 2023-03-08 | A2530 FS+17.5d, A2305 | 6.5d | 0d |
| A2560 |  | SUMINISTRO E INSTALACIÓN DE TEKNOPORT e=3/4" | 10d | 2023-02-24 | 2023-03-08 | A2550 SS, A2330 | 10.5d | 5d |
| A2570 |  | JUNTA con sellante expandible 1" x 3/4" | 10d | 2023-02-24 | 2023-03-08 | A2550 SS, A2340 | 10.5d | 5d |
| A2540 |  | ENCOFRADO Y DESENCOFRADO | 11d | 2023-03-01 | 2023-03-14 | A2550 SS+3d, A2310 | 5.5d | 0d |
| A2580 |  | CONCRETO F'C=280 Kg/cm2 - MURO | 5d | 2023-03-14 | 2023-03-20 | A2540, A2315, A2560, A2570 | 5.5d | 0d |
|  | 8 | **RETORNO EVACUADOR TOMA 4A** |  | 2023-01-16 | 2023-02-14 |  |  |  |
|  | 1 | **MOVIMIENTO DE TIERRAS** |  | 2023-01-16 | 2023-01-30 |  |  |  |
| A2350 |  | EXCAVACIÓN ESTRUCTURAL PARA OBRAS DE ARTE | 4d | 2023-01-16 | 2023-01-19 | A2500 | 28.75d | 0d |
| A2360 |  | CAMA DE ARENA | 1.25d | 2023-01-20 | 2023-01-21 | A2350 | 28.75d | 0d |
| A2370 |  | RELLENO ESTRUCTURAL PARA OBRAS DE ARTE CON MATERIAL PROPIO | 3d | 2023-01-26 | 2023-01-30 | A2420 | 28.75d | 0d |
|  | 2 | **OBRAS DE CONCRETO** |  | 2023-01-20 | 2023-02-14 |  |  |  |
|  | 1 | **CABEZAL ENTRADA** |  | 2023-01-20 | 2023-02-01 |  |  |  |
| A2380 |  | CONCRETO F'C=100 Kg/cm2 | 1.25d | 2023-01-20 | 2023-01-21 | A2350 | 61.75d | 0d |
| A2410 |  | ACERO DE REFUERZO Fy=4200 Kg/cm2 | 3d | 2023-01-25 | 2023-01-28 | A2380, A2590 | 58.75d | 0d |
| A2400 |  | ENCOFRADO Y DESENCOFRADO | 2d | 2023-01-28 | 2023-01-31 | A2410 | 66.75d | 0d |
| A2390 |  | CONCRETO F'C=280 Kg/cm2 | 1.25d | 2023-01-31 | 2023-02-01 | A2400, A2530 | 68.5d | 9.75d |
|  | 2 | **CABEZAL SALIDA** |  | 2023-01-21 | 2023-02-14 |  |  |  |
| A2600 |  | CONCRETO F'C=100 Kg/cm2 | 1.25d | 2023-01-21 | 2023-01-23 | A2380 | 63.5d | 4.75d |
| A2630 |  | ACERO DE REFUERZO Fy=4200 Kg/cm2 | 10d | 2023-01-28 | 2023-02-09 | A2600, A2410 | 58.75d | 0d |
| A2620 |  | ENCOFRADO Y DESENCOFRADO | 3d | 2023-02-09 | 2023-02-13 | A2630, A2400 | 58.75d | 0d |
| A2610 |  | CONCRETO F'C=280 Kg/cm2 | 1.25d | 2023-02-13 | 2023-02-14 | A2620, A2390 | 58.75d |  |

| ID | WBS | Activity | Duration | Start | Finish | Predecessors | Total float | Free float |
| --- | --- | --- | --- | --- | --- | --- | --- | --- |
|  | 3 | **TUBERÍAS** |  | 2023-01-21 | 2023-01-26 |  |  |  |
| A2420 |  | SUMINISTRO E INSTALACIÓN DE TUBERÍA HDPE DN600 mm | 4d | 2023-01-21 | 2023-01-26 | A2360 | 28.75d | 0d |
|  | 4 | **COMPUERTAS Y VÁLVULAS** |  | 2023-02-09 | 2023-02-14 |  |  |  |
| A2430 |  | COMPUERTA DE CHARNELA DN600 mm | 4d | 2023-02-09 | 2023-02-14 | A2630 | 59d |  |
|  | 9 | **PROGRAMA DE CIERRE DE OBRA** |  | 2023-01-16 | 2023-04-26 |  |  |  |
| A2440 |  | ACONDICIONAMIENTO DE DEPOSITOS DE MATERIALES EXCEDENTES (DME) | 44d | 2023-01-16 | 2023-03-07 | A1020 FS+18d | 46.25d |  |
| A2450 |  | RESTAURACIÓN DE ÁREAS DE INSTALACIONES PROVISIONALES | 2d | 2023-04-24 | 2023-04-26 | A2650 | 4d |  |
|  | 10 | **SEGURIDAD Y SALUD OCUPACIONAL** |  | 2022-12-17 | 2023-04-22 |  |  |  |
| A2460 |  | SEGURIDAD Y SALUD OCUPACIONAL | 109d | 2022-12-17 | 2023-04-22 | A1010 | 0.25d |  |
| A2470 |  | IMPLEMENTACIÓN DEL PLAN PARA LA VIGILANCIA, PREVENCIÓN Y CONTROL DE COVID-19 EN EL TRABAJO | 109d | 2022-12-17 | 2023-04-22 | A1010 | 0.25d |  |
